# 2011 Docking Plan

Schedule from MS Project, 2011-01-01 to 2012-03-30.
MBARI

## Calendars

- Standard: Mon-Fri 08:00-12:00, 13:00-17:00; Sat-Sun off.

## Resources

| Resource |
| --- |
| Lance |
| Brett |
| Thomas |
| Machine shop |
| Jon |
| Lance McBride |
| Thomas Hoover |
| Test Tank |
| Rob Mcewen |
| Zephyr |
| Brett Hobson |
| Jon Erickson |
| AUV Fabricator #1 |
| Mike Godin |
| Yanwu Zhang |
| Rich |
| EE |
| SE |
| ME |
| MS |
| RE |
| ET |
| MT |
| Rob |
| Robert |
| Jim |
| Denis |
| Etech |
| Benthos |
| Brian |

## Schedule

| ID | WBS | Task | Type | Duration | Start | Finish | Predecessors | Total slack | Free slack | Constraint | Resources | Work |
| --- | --- | --- | --- | --- | --- | --- | --- | --- | --- | --- | --- | --- |
| 1 | 1 | Power Buoy AUV Docking | milestone | 0d | 2011-01-01 | 2011-01-01 |  | 325d |  |  |  |  |
| 2 | 2 | **Project planning** |  | 33.33d? | 2011-01-03 | 2011-02-17 |  | 85.67d |  |  |  | 256h |
| 3 | 2.1 | Brainstorming |  | 33.33d? | 2011-01-03 | 2011-02-17 |  | 47.67d | 0d |  | Jim [10%]; Brett [10%]; Rob [10%] | 80h |
| 4 | 2.2 | Simulations |  | 15d? | 2011-01-03 | 2011-01-21 |  | 112d |  |  | Rob | 120h |
| 5 | 2.3 | Performance predictions |  | 1d? | 2011-01-03 | 2011-01-03 |  | 126d |  |  | Rob | 8h |
| 6 | 2.4 | **Plate measurements** |  | 6d? | 2011-01-18 | 2011-01-25 |  | 308d |  |  |  | 48h |
| 7 | 2.4.1 | design logger |  | 1d? | 2011-01-18 | 2011-01-18 |  | 110d | 0d | start no earlier than 2011-01-18 | Brett | 8h |
| 8 | 2.4.2 | order components |  | 1d? | 2011-01-19 | 2011-01-19 | 7 | 110d | 0d |  | Brett | 8h |
| 9 | 2.4.3 | assemble and bench test |  | 2d? | 2011-01-20 | 2011-01-21 | 8 | 110d | 0d |  | Brett | 16h |
| 10 | 2.4.4 | deployment |  | 2d? | 2011-01-24 | 2011-01-25 | 9 | 110d |  |  | Brett | 16h |
| 11 | 3 | **Homing system** |  | 94.67d? | 2011-02-17 | 2011-06-29 |  | 85.67d |  |  |  | 376h |
| 12 | 3.1 | Survey options |  | 1d? | 2011-02-17 | 2011-02-18 | 3 | 47.67d | 0d |  | Brett | 8h |
| 13 | 3.2 | Choose system | milestone | 0d | 2011-02-18 | 2011-02-18 | 12 | 47.67d | 0d |  |  |  |
| 14 | 3.3 | Negotiate and order |  | 1d? | 2011-02-18 | 2011-02-21 | 13 | 47.67d |  |  | Brett | 8h |
| 15 | 3.4 | Build and ship |  | 6w | 2011-04-28 | 2011-06-08 | 14 | 181d | 0d | start no earlier than 2011-04-28 | Benthos | 240h |
| 16 | 3.5 | Bench and tank test |  | 1d? | 2011-06-09 | 2011-06-09 | 15 | 181d | 0d |  | Brett | 8h |
| 17 | 3.6 | Return for calibration |  | 14d? | 2011-06-10 | 2011-06-29 | 16 | 181d | 0d |  | Benthos | 112h |
| 19 | 4 | **AUV** |  | 40d? | 2011-05-09 | 2011-07-01 |  | 30d |  |  |  | 288h |
| 20 | 4.1 | Design integrate DAT PCBs |  | 4d? | 2011-05-09 | 2011-05-12 | 13 | 30d | 0d | start no earlier than 2011-05-08 | Robert | 32h |
| 21 | 4.2 | Design integrate DAT Transducer |  | 4d? | 2011-05-13 | 2011-05-18 | 20 | 30d | 0d |  | Robert | 32h |
| 22 | 4.3 | Order long nose-cone |  | 1d? | 2011-05-19 | 2011-05-19 | 21 | 30d | 0d |  | Brett | 8h |
| 23 | 4.4 | Design brackets |  | 1d? | 2011-05-20 | 2011-05-20 | 22 | 30d | 0d |  | Robert | 8h |
| 24 | 4.5 | Modify endbell for 12 conductor port |  | 1d? | 2011-05-23 | 2011-05-23 | 23 | 192.5d | 0d |  | Brett | 8h |
| 25 | 4.6 | Check compass effects |  | 1d? | 2011-05-24 | 2011-05-24 | 24 | 192.5d | 0d |  | Denis | 8h |
| 26 | 4.7 | Design wiring harness |  | 1d? | 2011-05-25 | 2011-05-25 | 25 | 192.5d | 0d |  | Thomas | 8h |
| 27 | 4.8 | build wiring harness |  | 2w | 2011-05-26 | 2011-06-08 | 26 | 192.5d | 0d |  | Etech [10%] | 8h |
| 28 | 4.9 | Install 12 pin connector and wiring harness |  | 1d? | 2011-06-09 | 2011-06-09 | 27 | 192.5d | 0d |  | Thomas | 8h |
| 29 | 4.10 | Final integration and test |  | 2.5d? | 2011-06-10 | 2011-06-14 | 28 | 192.5d | 11.5d |  | Brett; Thomas | 40h |

| ID | WBS | Task | Duration | Start | Finish | Predecessors | Total slack | Free slack | Constraint | Resources | Work |
| --- | --- | --- | --- | --- | --- | --- | --- | --- | --- | --- | --- |
| 30 | 4.11 | **Software** | 16d? | 2011-06-10 | 2011-07-01 |  | 195d |  |  |  | 128h |
| 31 | 4.11.1 | Write DAT driver | 1d? | 2011-06-10 | 2011-06-10 | 16 | 195d | 0d |  | Brian | 8h |
| 32 | 4.11.2 | Modify existing homing code | 15d? | 2011-06-13 | 2011-07-01 | 31 | 195d |  |  | Rob | 120h |
| 33 | 5 | **Dock** | 190d | 2011-05-23 | 2012-02-10 |  | 30d |  |  |  | 196h |
| 34 | 5.1 | Design cone dock based on existing design | 90d | 2011-05-23 | 2011-09-23 | 23 | 30d | 0d | start no earlier than 2011-05-15 | Brett [5%]; Robert [20%] | 96h |
| 35 | 5.2 | Design and build test dock | 100d | 2011-09-26 | 2012-02-10 | 34 | 30d | 0d |  | Brett [5%]; Robert [35%] | 100h |
| 36 | 6 | **Testing** | 167d? | 2011-06-30 | 2012-02-17 |  | 30d |  |  |  | 384h |
| 37 | 6.1 | test prep | 3d | 2011-06-30 | 2011-07-04 | 29, 17 | 181d | 0d |  | Brett; Rob; Robert | 72h |
| 38 | 6.2 | Homing test 1 | 1d? | 2011-07-05 | 2011-07-05 | 16, 37 | 181d | 0d |  | Brett; Rob; Robert | 24h |
| 39 | 6.3 | test prep | 3d | 2011-07-06 | 2011-07-08 | 38 | 181d | 0d |  | Brett; Rob; Robert | 72h |
| 40 | 6.4 | Homing test 2 | 1d? | 2011-07-11 | 2011-07-11 | 39 | 181d | 29d |  | Brett; Rob; Robert | 24h |
| 41 | 6.5 | test prep | 3d | 2011-08-22 | 2011-08-24 | 40 | 152d | 122d | start no earlier than 2011-08-21 | Brett; Rob; Robert | 72h |
| 42 | 6.6 | Docking test 1 | 1d? | 2012-02-13 | 2012-02-13 | 35, 41 | 30d | 0d | start no earlier than 2011-08-28 | Brett; Rob; Robert | 24h |
| 43 | 6.7 | test prep | 3d | 2012-02-14 | 2012-02-16 | 42 | 30d | 0d | start no earlier than 2011-11-27 | Brett; Rob; Robert | 72h |
| 44 | 6.8 | Docking test 2 | 1d? | 2012-02-17 | 2012-02-17 | 43 | 30d |  | start no earlier than 2011-12-04 | Brett; Rob; Robert | 24h |
| 46 | 7 | **Misc.** | 325d? | 2011-01-03 | 2012-03-30 |  | 0d |  |  |  | 92h |
| 47 | 7.1 | **Meetings, Presentations, Documentation** | 325d? | 2011-01-03 | 2012-03-30 |  | 0d |  |  |  | 92h |
| 48 | 7.1.1 | Weekley meetings | 325d? | 2011-01-03 | 2012-03-30 |  | 0d |  |  | Brett [1%]; Rob [1%] | 52h |
| 49 | 7.1.2 | presentations | 2d? | 2011-01-03 | 2011-01-04 |  | 323d |  |  | Brett | 16h |
| 50 | 7.1.3 | work up project plan | 3d? | 2011-01-03 | 2011-01-05 |  | 322d |  |  | Brett | 24h |
